Schedule from MS Project, 2026-06-01 to 2026-10-16, A marks actual dates.
Microsoft

## Calendars

- 标准: Mon-Fri 08:00-12:00, 13:00-17:00; Sat-Sun off.

## Schedule

| ID | WBS | Task | Type | Duration | Start | Finish | Predecessors | Complete | Remaining | Total slack | Free slack | Constraint |
| --- | --- | --- | --- | --- | --- | --- | --- | --- | --- | --- | --- | --- |
| 2 | 1 | **Super-Ladder粘接到蜂窝板的装配工艺** |  | 77.12d | 2026-06-10 A | 2026-09-25 |  | 2% | 75.53d | 0d |  |  |
| 3 | 1.1 | 装配方案 | manual | 14d | 2026-06-29 | 2026-07-17 |  |  |  |  |  | start no earlier than 2026-06-29 |
| 4 | 1.2 | 蜂窝板底座加工 |  | 30d | 2026-07-17 | 2026-08-28 | 3 |  |  | 15d |  |  |
| 5 | 1.3 | 蜂窝板高精度定位和翻转工装加工 |  | 45d | 2026-07-17 | 2026-09-18 | 3 |  |  | 0d |  |  |
| 6 | 1.4 | super-ladder转移工装加工 |  | 30d | 2026-07-17 | 2026-08-28 | 3 |  |  | 15d |  |  |
| 7 | 1.5 | 假结构加工 |  | 30d | 2026-07-17 | 2026-08-28 | 3 |  |  | 20d |  |  |
| 8 | 1.6 | 蜂窝板加工 | manual | 72d | 2026-06-10 | 2026-09-17 |  |  |  |  |  | finish no earlier than 2026-09-17 |
| 9 | 1.7 | 蜂窝板试装配 |  | 5d | 2026-09-18 | 2026-09-25 | 8, 4, 5, 6 |  |  | 0d |  |  |
| 10 | 1.8 | AMS-02胶水购买 | manual | 5d | 2026-06-23 A | 2026-06-30 A |  | 100% |  |  |  | start no earlier than 2026-06-23 |
| 11 | 1.9 | DC3145胶水确认 | manual | 5d | 2026-06-25 | 2026-07-02 |  |  |  |  |  |  |
| 12 | 1.10 | 配重块确认 |  | 5d | 2026-07-24 | 2026-07-31 | 15 |  |  | 40d |  |  |
| 13 | 2 | **力学仿真及super-ladder装配方案** |  | 74d? | 2026-06-01 | 2026-09-11 |  |  |  | 0d |  |  |
| 14 | 2.1 | 盘点假硅片数量(SCD&STK) | manual | 7d | 2026-06-29 | 2026-07-08 |  |  |  |  |  |  |
| 15 | 2.2 | 完成Super-Ladder力学仿真(不同AIREX及点胶方案) | manual | 39d | 2026-06-01 | 2026-07-24 |  |  |  |  |  |  |
| 16 | 2.3 | 确认若干候选super-ladder装配方案 |  | 7d | 2026-07-24 | 2026-08-04 | 15, 14 |  |  | 10d | 0d |  |
| 17 | 2.4 | 加工假ASIC板 |  | 14d | 2026-08-04 | 2026-08-24 | 16 |  |  | 10d | 0d |  |
| 18 | 2.5 | 设计点胶图案 |  | 14d | 2026-08-04 | 2026-08-24 | 16 |  |  | 10d | 0d |  |
| 19 | 2.6 | 加工AIREX |  | 14d | 2026-08-04 | 2026-08-24 | 16 |  |  | 10d | 0d |  |
| 20 | 2.7 | 设计和加工AIREX定位工装 |  | 14d | 2026-08-04 | 2026-08-24 | 16 |  |  | 10d | 0d |  |
| 21 | 2.8 | 加工假导热索 |  | 14d | 2026-08-04 | 2026-08-24 | 16 |  |  | 10d | 0d |  |
| 22 | 2.9 | 装配待试super-ladder |  | 14d? | 2026-08-24 | 2026-09-11 | 21, 10, 11, 17, 18, 19, 20 |  |  | 10d |  |  |
| 23 | 3 | **摸底试验** |  | 60d | 2026-07-24 | 2026-10-16 |  |  |  | 0d |  |  |
| 24 | 3.1 | 摸底试验方案 |  | 7d | 2026-07-24 | 2026-08-04 | 15 |  |  | 1d | 0d |  |
| 25 | 3.2 | 预约试验 |  | 7d | 2026-07-24 | 2026-08-04 | 15 |  |  | 1d | 0d |  |
| 26 | 3.3 | 设计摸底试验工装 |  | 7d | 2026-08-04 | 2026-08-13 | 25, 24 |  |  | 1d | 0d |  |
| 27 | 3.4 | 加工摸底试验工装 |  | 30d | 2026-08-13 | 2026-09-24 | 26 |  |  | 1d |  |  |
| 28 | 3.5 | 设计运输包装箱 |  | 7d | 2026-08-04 | 2026-08-13 | 24 |  |  | 8d | 0d |  |
| 29 | 3.6 | 加工运输包装箱 |  | 30d | 2026-08-13 | 2026-09-24 | 28 |  |  | 8d |  |  |
| 30 | 3.7 | Super-Ladder粘接到蜂窝板 |  | 7d | 2026-09-25 | 2026-10-06 | 2, 13, 27 |  |  | 0d |  |  |
| 31 | 3.8 | 装到包装箱 |  | 1d | 2026-10-06 | 2026-10-07 | 30, 29 |  |  | 0d |  |  |
| 32 | 3.9 | 运输并试验 |  | 7d | 2026-10-07 | 2026-10-16 | 31 |  |  | 0d |  |  |
